# Planificación del TFG - Stelian Adrian Stanci

Schedule from MS Project, 2023-02-10 to 2023-11-08, costs in €, A marks actual dates.

## Calendars

- Estándar: Mon-Fri 09:00-13:00, 15:00-19:00; Sat-Sun off.

## Resources

| Resource | Rate |
| --- | --- |
| Alumno (investigador) | 15 |
| Alumno (ingeniero) | 15 |
| Alumno (jefe de proyecto) | 30 |
| Alumno (arquitecto) | 25 |
| Alumno (analista) | 20 |
| Equipo |  |

## Schedule

| ID | WBS | Task | Type | Duration | Start | Finish | Predecessors | Complete | Remaining | Total slack | Work | Actual work | Cost | Actual cost |
| --- | --- | --- | --- | --- | --- | --- | --- | --- | --- | --- | --- | --- | --- | --- |
| 1 | 1 | **Diseño e implementación de algoritmos cuánticos para problemas de optimización combinatoria** |  | 194d | 2023-02-10 A | 2023-11-08 |  | 99% | 0d | 0d | 391.58h | 391.58h | 6,993.75 | 6,993.75 |
| 2 | 1.1 | **Hitos** |  | 193.5d | 2023-02-10 | 2023-11-08 |  |  |  | 0.38d |  |  |  |  |
| 3 | 1.1.1 | Reunión de arranque | milestone | 0d | 2023-02-10 | 2023-02-10 | 113 |  |  | 193.88d |  |  |  |  |
| 4 | 1.1.2 | **Formación en computación cuántica** |  | 24.12d | 2023-03-01 | 2023-04-04 |  |  |  | 156.62d |  |  |  |  |
| 5 | 1.1.2.1 | Formación en las bases de la computación cuántica | milestone | 0d | 2023-03-01 | 2023-03-01 | 115 |  |  | 180.75d |  |  |  |  |
| 6 | 1.1.2.2 | **Formación en optimización cuántica** |  | 21.25d | 2023-03-06 | 2023-04-04 |  |  |  | 156.62d |  |  |  |  |
| 7 | 1.1.2.2.1 | **Formación en formulaciones y problemas** |  | 9.12d | 2023-03-06 | 2023-03-17 |  |  |  | 168.75d |  |  |  |  |
| 8 | 1.1.2.2.1.1 | Formación en el framework QUBO | milestone | 0d | 2023-03-06 | 2023-03-06 | 118 |  |  | 177.88d |  |  |  |  |
| 9 | 1.1.2.2.1.2 | Formación en el modelo de Ising | milestone | 0d | 2023-03-07 | 2023-03-07 | 119 |  |  | 176.62d |  |  |  |  |
| 10 | 1.1.2.2.1.3 | Formación en paso de Ising a QUBO | milestone | 0d | 2023-03-08 | 2023-03-08 | 120 |  |  | 175.62d |  |  |  |  |
| 11 | 1.1.2.2.1.4 | Formación en representación de problemas de optimización combinatoria | milestone | 0d | 2023-03-17 | 2023-03-17 | 121 |  |  | 168.75d |  |  |  |  |
| 12 | 1.1.2.2.2 | **Formación en annealing cuántico** |  | 3.75d | 2023-03-21 | 2023-03-27 |  |  |  | 162.88d |  |  |  |  |
| 13 | 1.1.2.2.2.1 | Formación en computación adiabática | milestone | 0d | 2023-03-21 | 2023-03-21 | 123 |  |  | 166.62d |  |  |  |  |
| 14 | 1.1.2.2.2.2 | Formación en annealing cuántico | milestone | 0d | 2023-03-23 | 2023-03-23 | 124 |  |  | 164.75d |  |  |  |  |
| 15 | 1.1.2.2.2.3 | Formación en uso de annealers de D-Wave | milestone | 0d | 2023-03-27 | 2023-03-27 | 125 |  |  | 162.88d |  |  |  |  |
| 16 | 1.1.2.2.3 | **Formación en QAOA** |  | 5d | 2023-03-28 | 2023-04-04 |  |  |  | 156.62d |  |  |  |  |
| 17 | 1.1.2.2.3.1 | Formación en paso de annealing cuántico a QAOA | milestone | 0d | 2023-03-28 | 2023-03-28 | 127 |  |  | 161.62d |  |  |  |  |
| 18 | 1.1.2.2.3.2 | Formación en resolución de problemas utilizando el QAOA | milestone | 0d | 2023-04-04 | 2023-04-04 | 128 |  |  | 156.62d |  |  |  |  |
| 19 | 1.1.3 | **Realización del estudio** |  | 16d | 2023-04-24 | 2023-05-16 |  |  |  | 126.88d |  |  |  |  |
| 20 | 1.1.3.1 | Estudio del Max-Cut | milestone | 0d | 2023-04-24 | 2023-04-24 | 130 |  |  | 142.88d |  |  |  |  |
| 21 | 1.1.3.2 | Estudio del TSP | milestone | 0d | 2023-05-03 | 2023-05-03 | 134 |  |  | 135.88d |  |  |  |  |
| 22 | 1.1.3.3 | Estudio del problema de la mochila | milestone | 0d | 2023-05-09 | 2023-05-09 | 138 |  |  | 131.88d |  |  |  |  |
| 23 | 1.1.3.4 | Estudio del problema del coloreado de grafos | milestone | 0d | 2023-05-16 | 2023-05-16 | 142 |  |  | 126.88d |  |  |  |  |
| 24 | 1.1.4 | **Desarrollo de aplicación web** |  | 24d | 2023-04-18 | 2023-05-22 |  |  |  | 122.25d |  |  |  |  |
| 25 | 1.1.4.1 | Formación en Flask | milestone | 0d | 2023-04-18 | 2023-04-18 | 147 |  |  | 146.25d |  |  |  |  |
| 26 | 1.1.4.2 | Implementación página principal | milestone | 0d | 2023-04-19 | 2023-04-19 | 148 |  |  | 145.12d |  |  |  |  |
| 27 | 1.1.4.3 | Página Max-Cut | milestone | 0d | 2023-05-02 | 2023-05-02 | 149 |  |  | 136.12d |  |  |  |  |
| 28 | 1.1.4.4 | Página TSP | milestone | 0d | 2023-05-09 | 2023-05-09 | 153 |  |  | 131.25d |  |  |  |  |
| 29 | 1.1.4.5 | Página del problema de la mochila | milestone | 0d | 2023-05-15 | 2023-05-15 | 157 |  |  | 127.25d |  |  |  |  |
| 30 | 1.1.4.6 | Página del problema del coloreado de grafos | milestone | 0d | 2023-05-22 | 2023-05-22 | 161 |  |  | 122.25d |  |  |  |  |

| ID | WBS | Task | Type | Duration | Start | Finish | Predecessors | Total slack |
| --- | --- | --- | --- | --- | --- | --- | --- | --- |
| 31 | 1.1.5 | **Documentación del proyecto** |  | 156d | 2023-04-04 | 2023-11-08 |  | 0.5d |
| 32 | 1.1.5.1 | Abstract | milestone | 0d | 2023-09-01 | 2023-09-01 | 166 | 48.88d |
| 33 | 1.1.5.2 | **Introducción** |  | 10.12d | 2023-09-04 | 2023-09-18 |  | 37.62d |
| 34 | 1.1.5.2.1 | Motivación | milestone | 0d | 2023-09-04 | 2023-09-04 | 168 | 47.75d |
| 35 | 1.1.5.2.2 | Finalidad del proyecto | milestone | 0d | 2023-09-04 | 2023-09-04 | 169 | 47.62d |
| 36 | 1.1.5.2.3 | Marco teórico | milestone | 0d | 2023-09-18 | 2023-09-18 | 170 | 37.62d |
| 37 | 1.1.5.3 | Fijación de objetivos | milestone | 0d | 2023-09-20 | 2023-09-20 | 171 | 35.75d |
| 38 | 1.1.5.4 | **Planificación y gestión del TFG** |  | 156d | 2023-04-04 | 2023-11-08 |  | 0.5d |
| 39 | 1.1.5.4.1 | **Planificación del proyecto** |  | 7.38d | 2023-04-04 | 2023-04-13 |  | 149.12d |
| 40 | 1.1.5.4.1.1 | Identificación de interesados | milestone | 0d | 2023-04-04 | 2023-04-04 | 174 | 156.5d |
| 41 | 1.1.5.4.1.2 | OBS | milestone | 0d | 2023-04-04 | 2023-04-04 | 175 | 156.25d |
| 42 | 1.1.5.4.1.3 | PBS | milestone | 0d | 2023-04-06 | 2023-04-06 | 176 | 154.62d |
| 43 | 1.1.5.4.1.4 | WBS | milestone | 0d | 2023-04-11 | 2023-04-11 | 177 | 151.25d |
| 44 | 1.1.5.4.1.5 | **Riesgos** |  | 0.88d | 2023-04-11 | 2023-04-12 |  | 150.12d |
| 45 | 1.1.5.4.1.5.1 | Plan de gestión de riesgos | milestone | 0d | 2023-04-11 | 2023-04-11 | 179 | 151d |
| 46 | 1.1.5.4.1.5.2 | Identificación de riesgos | milestone | 0d | 2023-04-12 | 2023-04-12 | 180 | 150.12d |
| 47 | 1.1.5.4.1.6 | **Presupuesto inicial del TFG** |  | 0.25d | 2023-04-13 | 2023-04-13 |  | 149.12d |
| 48 | 1.1.5.4.1.6.1 | Presupuesto de costes | milestone | 0d | 2023-04-13 | 2023-04-13 | 182 | 149.38d |
| 49 | 1.1.5.4.1.6.2 | Presupuesto de cliente | milestone | 0d | 2023-04-13 | 2023-04-13 | 183 | 149.12d |
| 50 | 1.1.5.4.2 | **Ejecución del proyecto** |  | 0.75d | 2023-11-06 | 2023-11-06 |  | 2d |
| 51 | 1.1.5.4.2.1 | Plan de seguimiento de planificación | milestone | 0d | 2023-11-06 | 2023-11-06 | 185 | 2.75d |
| 52 | 1.1.5.4.2.2 | Bitácora de incidencias del proyecto | milestone | 0d | 2023-11-06 | 2023-11-06 | 186 | 2.25d |
| 53 | 1.1.5.4.2.3 | Riesgos | milestone | 0d | 2023-11-06 | 2023-11-06 | 187 | 2d |
| 54 | 1.1.5.4.3 | **Cierre del proyecto** |  | 1.38d | 2023-11-07 | 2023-11-08 |  | 0.5d |
| 55 | 1.1.5.4.3.1 | Planificación final | milestone | 0d | 2023-11-07 | 2023-11-07 | 189 | 1.88d |
| 56 | 1.1.5.4.3.2 | Informe final de riesgos | milestone | 0d | 2023-11-07 | 2023-11-07 | 190 | 1.25d |
| 57 | 1.1.5.4.3.3 | Presupuesto final de costes | milestone | 0d | 2023-11-08 | 2023-11-08 | 191 | 0.88d |
| 58 | 1.1.5.4.3.4 | Informe de lecciones aprendidas | milestone | 0d | 2023-11-08 | 2023-11-08 | 192 | 0.5d |
| 59 | 1.1.5.5 | Estado del arte | milestone | 0d | 2023-09-29 | 2023-09-29 | 193 | 28.88d |

| ID | WBS | Task | Type | Duration | Start | Finish | Predecessors | Total slack |
| --- | --- | --- | --- | --- | --- | --- | --- | --- |
| 60 | 1.1.5.6 | **Descripción del sistema** |  | 10.12d | 2023-09-29 | 2023-10-13 |  | 18.62d |
| 61 | 1.1.5.6.1 | **Formulaciones** |  | 0.88d | 2023-09-29 | 2023-10-02 |  | 27.88d |
| 62 | 1.1.5.6.1.1 | Framework QUBO | milestone | 0d | 2023-09-29 | 2023-09-29 | 196 | 28.75d |
| 63 | 1.1.5.6.1.2 | Modelo de Ising | milestone | 0d | 2023-10-02 | 2023-10-02 | 197 | 27.88d |
| 64 | 1.1.5.6.2 | **Problemas** |  | 3.88d | 2023-10-02 | 2023-10-06 |  | 23.75d |
| 65 | 1.1.5.6.2.1 | Max-Cut | milestone | 0d | 2023-10-02 | 2023-10-02 | 199 | 27.62d |
| 66 | 1.1.5.6.2.2 | Programación lineal binaria | milestone | 0d | 2023-10-03 | 2023-10-03 | 200 | 26.62d |
| 67 | 1.1.5.6.2.3 | TSP | milestone | 0d | 2023-10-04 | 2023-10-04 | 201 | 25.62d |
| 68 | 1.1.5.6.2.4 | Problema de la mochila | milestone | 0d | 2023-10-05 | 2023-10-05 | 202 | 24.75d |
| 69 | 1.1.5.6.2.5 | Problema del coloreado de grafos | milestone | 0d | 2023-10-06 | 2023-10-06 | 203 | 23.75d |
| 70 | 1.1.5.6.3 | **Métodos** |  | 4.12d | 2023-10-09 | 2023-10-13 |  | 18.62d |
| 71 | 1.1.5.6.3.1 | **Annealing cuántico** |  | 0.88d | 2023-10-09 | 2023-10-10 |  | 21.88d |
| 72 | 1.1.5.6.3.1.1 | Computación adiabática cuántica | milestone | 0d | 2023-10-09 | 2023-10-09 | 206 | 22.75d |
| 73 | 1.1.5.6.3.1.2 | Annealing cuántico | milestone | 0d | 2023-10-10 | 2023-10-10 | 207 | 21.88d |
| 74 | 1.1.5.6.3.2 | **QAOA** |  | 3d | 2023-10-10 | 2023-10-13 |  | 18.62d |
| 75 | 1.1.5.6.3.2.1 | Definición | milestone | 0d | 2023-10-10 | 2023-10-10 | 209 | 21.62d |
| 76 | 1.1.5.6.3.2.2 | Algoritmo | milestone | 0d | 2023-10-11 | 2023-10-11 | 210 | 20.62d |
| 77 | 1.1.5.6.3.2.3 | Paso a circuitos | milestone | 0d | 2023-10-13 | 2023-10-13 | 211 | 18.62d |
| 78 | 1.1.5.7 | **Metodología de trabajo** |  | 5.42d | 2023-10-16 | 2023-10-23 |  | 12.33d |
| 79 | 1.1.5.7.1 | Explicación de métodos a utilizar | milestone | 0d | 2023-10-16 | 2023-10-16 | 213 | 17.75d |
| 80 | 1.1.5.7.2 | **Max-Cut** |  | 1.47d | 2023-10-16 | 2023-10-17 |  | 16.25d |
| 81 | 1.1.5.7.2.1 | Datos utilizados | milestone | 0d | 2023-10-16 | 2023-10-16 | 215 | 17.72d |
| 82 | 1.1.5.7.2.2 | Formulación del problema | milestone | 0d | 2023-10-16 | 2023-10-16 | 216 | 17.25d |
| 83 | 1.1.5.7.2.3 | Ejecución del problema | milestone | 0d | 2023-10-17 | 2023-10-17 | 217 | 16.25d |

| ID | WBS | Task | Type | Duration | Start | Finish | Predecessors | Total slack |
| --- | --- | --- | --- | --- | --- | --- | --- | --- |
| 84 | 1.1.5.7.3 | **TSP** |  | 1.72d | 2023-10-18 | 2023-10-19 |  | 14.25d |
| 85 | 1.1.5.7.3.1 | Datos utilizados | milestone | 0d | 2023-10-18 | 2023-10-18 | 219 | 15.97d |
| 86 | 1.1.5.7.3.2 | Formulación del problema | milestone | 0d | 2023-10-18 | 2023-10-18 | 220 | 15.12d |
| 87 | 1.1.5.7.3.3 | Ejecución del problema | milestone | 0d | 2023-10-19 | 2023-10-19 | 221 | 14.25d |
| 88 | 1.1.5.7.4 | **Problema de la mochila** |  | 0.69d | 2023-10-20 | 2023-10-20 |  | 13.28d |
| 89 | 1.1.5.7.4.1 | Datos utilizados | milestone | 0d | 2023-10-20 | 2023-10-20 | 223 | 13.97d |
| 90 | 1.1.5.7.4.2 | Formulación del problema | milestone | 0d | 2023-10-20 | 2023-10-20 | 224 | 13.31d |
| 91 | 1.1.5.7.4.3 | Ejecución del problema | milestone | 0d | 2023-10-20 | 2023-10-20 | 225 | 13.28d |
| 92 | 1.1.5.7.5 | **Problema del coloreado de grafos** |  | 0.64d | 2023-10-23 | 2023-10-23 |  | 12.33d |
| 93 | 1.1.5.7.5.1 | Datos utilizados | milestone | 0d | 2023-10-23 | 2023-10-23 | 227 | 12.97d |
| 94 | 1.1.5.7.5.2 | Formulación del problema | milestone | 0d | 2023-10-23 | 2023-10-23 | 228 | 12.35d |
| 95 | 1.1.5.7.5.3 | Ejecución del problema | milestone | 0d | 2023-10-23 | 2023-10-23 | 229 | 12.33d |
| 96 | 1.1.5.8 | **Resultados obtenidos** |  | 2d | 2023-10-24 | 2023-10-26 |  | 9.88d |
| 97 | 1.1.5.8.1 | **Presentación de los resultados** |  | 1d | 2023-10-24 | 2023-10-25 |  | 10.88d |
| 98 | 1.1.5.8.1.1 | Max-Cut | milestone | 0d | 2023-10-24 | 2023-10-24 | 232 | 11.88d |
| 99 | 1.1.5.8.1.2 | TSP | milestone | 0d | 2023-10-24 | 2023-10-24 | 233 | 11.75d |
| 100 | 1.1.5.8.1.3 | Problema de la mochila | milestone | 0d | 2023-10-24 | 2023-10-24 | 234 | 11.62d |
| 101 | 1.1.5.8.1.4 | Problema del coloreado de grafos | milestone | 0d | 2023-10-25 | 2023-10-25 | 235 | 10.88d |
| 102 | 1.1.5.8.2 | Discusión de los resultados | milestone | 0d | 2023-10-26 | 2023-10-26 | 236 | 9.88d |
| 103 | 1.1.5.9 | **Conclusiones y trabajo futuro** |  | 0.66d | 2023-10-26 | 2023-10-27 |  | 8.97d |
| 104 | 1.1.5.9.1 | Trabajo futuro | milestone | 0d | 2023-10-26 | 2023-10-26 | 238 | 9.62d |
| 105 | 1.1.5.9.2 | Difusión de resultados | milestone | 0d | 2023-10-27 | 2023-10-27 | 239 | 8.97d |
| 106 | 1.1.5.10 | Bibliografía | milestone | 0d | 2023-10-27 | 2023-10-27 | 240 | 8.94d |
| 107 | 1.1.5.11 | **Anexos** |  | 5.56d | 2023-10-27 | 2023-11-03 |  | 3.12d |
| 108 | 1.1.5.11.1 | Plan de gestión de riesgos | milestone | 0d | 2023-10-27 | 2023-10-27 | 242 | 8.69d |
| 109 | 1.1.5.11.2 | Presupuesto | milestone | 0d | 2023-10-27 | 2023-10-27 | 243 | 8.06d |
| 110 | 1.1.5.11.3 | Aplicación web | milestone | 0d | 2023-11-03 | 2023-11-03 | 244 | 3.12d |
| 111 | 1.1.6 | Reunión de cierre | milestone | 0d | 2023-11-08 | 2023-11-08 | 245 | 0.38d |

| ID | WBS | Task | Duration | Start | Finish | Predecessors | Complete | Resources | Work | Actual work | Cost | Actual cost |
| --- | --- | --- | --- | --- | --- | --- | --- | --- | --- | --- | --- | --- |
| 112 | 1.2 | **Actividades** | 194d | 2023-02-10 A | 2023-11-08 A |  | 100% |  | 391.58h | 391.58h | 6,993.75 | 6,993.75 |
| 113 | 1.2.1 | Reunión de arranque | 1h | 2023-02-10 A | 2023-02-10 A |  | 100% | Alumno (jefe de proyecto) | 1h | 1h | 30 | 30 |
| 114 | 1.2.2 | **Formación en computación cuántica** | 37.25d | 2023-02-10 A | 2023-04-04 A |  | 100% |  | 111h | 111h | 1,665 | 1,665 |
| 115 | 1.2.2.1 | Formación en las bases de la computación cuántica | 40h | 2023-02-10 A | 2023-03-01 A |  | 100% | Alumno (investigador) | 40h | 40h | 600 | 600 |
| 116 | 1.2.2.2 | **Formación en optimización cuántica** | 24.12d | 2023-03-01 A | 2023-04-04 A |  | 100% |  | 71h | 71h | 1,065 | 1,065 |
| 117 | 1.2.2.2.1 | **Formación en formulaciones y problemas** | 12d | 2023-03-01 A | 2023-03-17 A |  | 100% |  | 34h | 34h | 510 | 510 |
| 118 | 1.2.2.2.1.1 | Formación en el framework QUBO | 6h | 2023-03-01 A | 2023-03-06 A | 115 | 100% | Alumno (investigador) | 6h | 6h | 90 | 90 |
| 119 | 1.2.2.2.1.2 | Formación en el modelo de Ising | 5h | 2023-03-06 A | 2023-03-07 A | 118 | 100% | Alumno (investigador) | 5h | 5h | 75 | 75 |
| 120 | 1.2.2.2.1.3 | Formación en paso de Ising a QUBO | 3h | 2023-03-08 A | 2023-03-08 A | 119 | 100% | Alumno (investigador) | 3h | 3h | 45 | 45 |
| 121 | 1.2.2.2.1.4 | Formación en representación de problemas de optimización combinatoria | 20h | 2023-03-09 A | 2023-03-17 A | 120 | 100% | Alumno (investigador) | 20h | 20h | 300 | 300 |
| 122 | 1.2.2.2.2 | **Formación en annealing cuántico** | 5.88d | 2023-03-17 A | 2023-03-27 A |  | 100% |  | 17h | 17h | 255 | 255 |
| 123 | 1.2.2.2.2.1 | Formación en computación adiabática | 7h | 2023-03-17 A | 2023-03-21 A | 121 | 100% | Alumno (investigador) | 7h | 7h | 105 | 105 |
| 124 | 1.2.2.2.2.2 | Formación en annealing cuántico | 5h | 2023-03-22 A | 2023-03-23 A | 123 | 100% | Alumno (investigador) | 5h | 5h | 75 | 75 |
| 125 | 1.2.2.2.2.3 | Formación en uso de annealers de D-Wave | 5h | 2023-03-23 A | 2023-03-27 A | 124 | 100% | Alumno (investigador) | 5h | 5h | 75 | 75 |
| 126 | 1.2.2.2.3 | **Formación en QAOA** | 6.25d | 2023-03-27 A | 2023-04-04 A |  | 100% |  | 20h | 20h | 300 | 300 |
| 127 | 1.2.2.2.3.1 | Formación en paso de annealing cuántico a QAOA | 5h | 2023-03-27 A | 2023-03-28 A | 125 | 100% | Alumno (investigador) | 5h | 5h | 75 | 75 |
| 128 | 1.2.2.2.3.2 | Formación en resolución de problemas utilizando el QAOA | 15h | 2023-03-29 A | 2023-04-04 A | 127 | 100% | Alumno (investigador) | 15h | 15h | 225 | 225 |
| 129 | 1.2.3 | **Realización del estudio** | 22.12d | 2023-04-14 A | 2023-05-16 A | 114 | 100% |  | 19h | 19h | 285 | 285 |
| 130 | 1.2.3.1 | **Estudio del Max-Cut** | 6.12d | 2023-04-14 A | 2023-04-24 A |  | 100% |  | 3h | 3h | 45 | 45 |
| 131 | 1.2.3.1.1 | Generación de grafos | 2h | 2023-04-14 A | 2023-04-14 A | 173 | 100% | Alumno (investigador) | 2h | 2h | 30 | 30 |
| 132 | 1.2.3.1.2 | Resolución de los grafos | 45h | 2023-04-14 A | 2023-04-21 A | 131 | 100% | Equipo [0.1%] |  |  |  |  |
| 133 | 1.2.3.1.3 | Procesamiento de los resultados | 1h | 2023-04-24 A | 2023-04-24 A | 132 | 100% | Alumno (investigador) | 1h | 1h | 15 | 15 |
| 134 | 1.2.3.2 | **Estudio del TSP** | 7d | 2023-04-24 A | 2023-05-03 A | 130 | 100% |  | 11h | 11h | 165 | 165 |
| 135 | 1.2.3.2.1 | Generación de grafos | 10h | 2023-04-24 A | 2023-04-27 A |  | 100% | Alumno (investigador) | 10h | 10h | 150 | 150 |
| 136 | 1.2.3.2.2 | Resolución de los grafos | 25h | 2023-04-27 A | 2023-05-02 A | 135 | 100% | Equipo [0.1%] |  |  |  |  |
| 137 | 1.2.3.2.3 | Procesamiento de los resultados | 1h | 2023-05-03 A | 2023-05-03 A | 136 | 100% | Alumno (investigador) | 1h | 1h | 15 | 15 |

| ID | WBS | Task | Duration | Start | Finish | Predecessors | Complete | Resources | Work | Actual work | Cost | Actual cost |
| --- | --- | --- | --- | --- | --- | --- | --- | --- | --- | --- | --- | --- |
| 138 | 1.2.3.3 | **Estudio del problema de la mochila** | 4d | 2023-05-03 A | 2023-05-09 A | 134 | 100% |  | 2h | 2h | 30 | 30 |
| 139 | 1.2.3.3.1 | Generación de grafos | 1h | 2023-05-03 A | 2023-05-03 A | 137 | 100% | Alumno (investigador) | 1h | 1h | 15 | 15 |
| 140 | 1.2.3.3.2 | Resolución de los grafos | 30h | 2023-05-03 A | 2023-05-08 A | 139 | 100% | Equipo [0.1%] |  |  |  |  |
| 141 | 1.2.3.3.3 | Procesamiento de los resultados | 1h | 2023-05-09 A | 2023-05-09 A | 140 | 100% | Alumno (investigador) | 1h | 1h | 15 | 15 |
| 142 | 1.2.3.4 | **Estudio del problema del coloreado de grafos** | 5d | 2023-05-09 A | 2023-05-16 A | 138 | 100% |  | 3h | 3h | 45 | 45 |
| 143 | 1.2.3.4.1 | Generación de grafos | 2h | 2023-05-09 A | 2023-05-09 A | 141 | 100% | Alumno (investigador) | 2h | 2h | 30 | 30 |
| 144 | 1.2.3.4.2 | Resolución de los grafos | 35h | 2023-05-09 A | 2023-05-15 A | 143 | 100% | Equipo [0.1%] |  |  |  |  |
| 145 | 1.2.3.4.3 | Procesamiento de los resultados | 1h | 2023-05-16 A | 2023-05-16 A | 144 | 100% | Alumno (investigador) | 1h | 1h | 15 | 15 |
| 146 | 1.2.4 | **Desarrollo de aplicación web** | 26.12d | 2023-04-14 A | 2023-05-22 A | 173 | 100% |  | 53h | 53h | 795 | 795 |
| 147 | 1.2.4.1 | Formación en Flask | 5h | 2023-04-14 A | 2023-04-18 A | 114 | 100% | Alumno (ingeniero) | 5h | 5h | 75 | 75 |
| 148 | 1.2.4.2 | Implementación página principal | 3h | 2023-04-18 A | 2023-04-19 A | 147 | 100% | Alumno (ingeniero) | 3h | 3h | 45 | 45 |
| 149 | 1.2.4.3 | **Página Max-Cut** | 8.25d | 2023-04-20 A | 2023-05-02 A |  | 100% |  | 18h | 18h | 270 | 270 |
| 150 | 1.2.4.3.1 | Implementación de las distintas formas de resolver los problemas | 10h | 2023-04-20 A | 2023-04-26 A | 148 | 100% | Alumno (ingeniero) | 10h | 10h | 150 | 150 |
| 151 | 1.2.4.3.2 | Parametrización de los problemas | 5h | 2023-04-27 A | 2023-05-01 A | 150 | 100% | Alumno (ingeniero) | 5h | 5h | 75 | 75 |
| 152 | 1.2.4.3.3 | Carga de problema a través de fichero | 3h | 2023-05-01 A | 2023-05-02 A | 151 | 100% | Alumno (ingeniero) | 3h | 3h | 45 | 45 |
| 153 | 1.2.4.4 | **Página TSP** | 4.12d | 2023-05-03 A | 2023-05-09 A | 149 | 100% |  | 9h | 9h | 135 | 135 |
| 154 | 1.2.4.4.1 | Implementación de las distintas formas de resolver los problemas | 1h | 2023-05-03 A | 2023-05-03 A |  | 100% | Alumno (ingeniero) | 1h | 1h | 15 | 15 |
| 155 | 1.2.4.4.2 | Parametrización de los problemas | 5h | 2023-05-03 A | 2023-05-05 A | 154 | 100% | Alumno (ingeniero) | 5h | 5h | 75 | 75 |
| 156 | 1.2.4.4.3 | Carga de problema a través de fichero | 3h | 2023-05-08 A | 2023-05-09 A | 155 | 100% | Alumno (ingeniero) | 3h | 3h | 45 | 45 |
| 157 | 1.2.4.5 | **Página del problema de la mochila** | 4d | 2023-05-09 A | 2023-05-15 A | 153 | 100% |  | 8h | 8h | 120 | 120 |
| 158 | 1.2.4.5.1 | Implementación de las distintas formas de resolver los problemas | 1h | 2023-05-09 A | 2023-05-09 A | 156 | 100% | Alumno (ingeniero) | 1h | 1h | 15 | 15 |
| 159 | 1.2.4.5.2 | Parametrización de los problemas | 3h | 2023-05-10 A | 2023-05-11 A | 158 | 100% | Alumno (ingeniero) | 3h | 3h | 45 | 45 |
| 160 | 1.2.4.5.3 | Carga de problema a través de fichero | 4h | 2023-05-11 A | 2023-05-15 A | 159 | 100% | Alumno (ingeniero) | 4h | 4h | 60 | 60 |
| 161 | 1.2.4.6 | **Página del problema del coloreado de grafos** | 5d | 2023-05-15 A | 2023-05-22 A | 157 | 100% |  | 10h | 10h | 150 | 150 |
| 162 | 1.2.4.6.1 | Implementación de las distintas formas de resolver los problemas | 1h | 2023-05-15 A | 2023-05-15 A | 160 | 100% | Alumno (ingeniero) | 1h | 1h | 15 | 15 |
| 163 | 1.2.4.6.2 | Parametrización de los problemas | 5h | 2023-05-16 A | 2023-05-18 A | 162 | 100% | Alumno (ingeniero) | 5h | 5h | 75 | 75 |
| 164 | 1.2.4.6.3 | Carga de problema a través de fichero | 4h | 2023-05-18 A | 2023-05-22 A | 163 | 100% | Alumno (ingeniero) | 4h | 4h | 60 | 60 |

| ID | WBS | Task | Type | Duration | Start | Finish | Predecessors | Complete | Constraint | Resources | Work | Actual work | Cost | Actual cost |
| --- | --- | --- | --- | --- | --- | --- | --- | --- | --- | --- | --- | --- | --- | --- |
| 165 | 1.2.5 | **Documentación del proyecto** |  | 156.12d | 2023-04-04 A | 2023-11-08 A |  | 100% |  |  | 206.58h | 206.58h | 4,188.75 | 4,188.75 |
| 166 | 1.2.5.1 | Abstract | manual | 1h | 2023-09-01 A | 2023-09-01 A |  | 100% |  | Alumno (investigador) | 1h | 1h | 15 | 15 |
| 167 | 1.2.5.2 | **Introducción** |  | 11.25d | 2023-09-01 A | 2023-09-18 A |  | 100% |  |  | 35h | 35h | 525 | 525 |
| 168 | 1.2.5.2.1 | Motivación |  | 4h | 2023-09-01 A | 2023-09-04 A | 166 | 100% |  | Alumno (investigador) | 4h | 4h | 60 | 60 |
| 169 | 1.2.5.2.2 | Finalidad del proyecto |  | 1h | 2023-09-04 A | 2023-09-04 A | 168 | 100% |  | Alumno (investigador) | 1h | 1h | 15 | 15 |
| 170 | 1.2.5.2.3 | Marco teórico |  | 30h | 2023-09-05 A | 2023-09-18 A | 169 | 100% |  | Alumno (investigador) | 30h | 30h | 450 | 450 |
| 171 | 1.2.5.3 | Fijación de objetivos |  | 5h | 2023-09-19 A | 2023-09-20 A | 170 | 100% |  | Alumno (investigador) | 5h | 5h | 75 | 75 |
| 172 | 1.2.5.4 | **Planificación y gestión del TFG** |  | 156.12d | 2023-04-04 A | 2023-11-08 A |  | 100% |  |  | 77h | 77h | 2,170 | 2,170 |
| 173 | 1.2.5.4.1 | **Planificación del proyecto** |  | 7.5d | 2023-04-04 A | 2023-04-13 A |  | 100% |  |  | 56h | 56h | 1,575 | 1,575 |
| 174 | 1.2.5.4.1.1 | Identificación de interesados |  | 1h | 2023-04-04 A | 2023-04-04 A | 114 | 100% |  | Alumno (analista); Alumno (jefe de proyecto) | 1h | 1h | 30 | 30 |
| 175 | 1.2.5.4.1.2 | OBS |  | 2h | 2023-04-04 A | 2023-04-04 A | 174 | 100% |  | Alumno (arquitecto); Alumno (jefe de proyecto) | 2h | 2h | 55 | 55 |
| 176 | 1.2.5.4.1.3 | PBS |  | 6h | 2023-04-04 A | 2023-04-06 A | 175 | 100% | start no earlier than 2023-03-20 | Alumno (arquitecto); Alumno (jefe de proyecto) | 8h | 8h | 230 | 230 |
| 177 | 1.2.5.4.1.4 | WBS |  | 20h | 2023-04-06 A | 2023-04-11 A | 176 | 100% | start no earlier than 2023-03-22 | Alumno (arquitecto); Alumno (jefe de proyecto) | 23h | 23h | 625 | 625 |
| 178 | 1.2.5.4.1.5 | **Riesgos** |  | 1.12d | 2023-04-11 A | 2023-04-12 A |  | 100% |  |  | 14h | 14h | 395 | 395 |
| 179 | 1.2.5.4.1.5.1 | Plan de gestión de riesgos |  | 2h | 2023-04-11 A | 2023-04-11 A | 177 | 100% |  | Alumno (jefe de proyecto); Alumno (arquitecto) | 4h | 4h | 110 | 110 |
| 180 | 1.2.5.4.1.5.2 | Identificación de riesgos |  | 8h | 2023-04-11 A | 2023-04-12 A | 179 | 100% |  | Alumno (jefe de proyecto); Alumno (arquitecto) | 10h | 10h | 285 | 285 |
| 181 | 1.2.5.4.1.6 | **Presupuesto inicial del TFG** |  | 1d | 2023-04-12 A | 2023-04-13 A |  | 100% |  |  | 8h | 8h | 240 | 240 |
| 182 | 1.2.5.4.1.6.1 | Presupuesto de costes |  | 6h | 2023-04-12 A | 2023-04-13 A | 180 | 100% |  | Alumno (jefe de proyecto) | 6h | 6h | 180 | 180 |
| 183 | 1.2.5.4.1.6.2 | Presupuesto de cliente |  | 2h | 2023-04-13 A | 2023-04-13 A | 182 | 100% |  | Alumno (jefe de proyecto) | 2h | 2h | 60 | 60 |
| 184 | 1.2.5.4.2 | **Ejecución del proyecto** |  | 1.12d | 2023-11-03 A | 2023-11-06 A |  | 100% |  |  | 11h | 11h | 305 | 305 |
| 185 | 1.2.5.4.2.1 | Plan de seguimiento de planificación |  | 4h | 2023-11-03 A | 2023-11-06 A | 244 | 100% |  | Alumno (jefe de proyecto); Alumno (arquitecto) | 5h | 5h | 140 | 140 |
| 186 | 1.2.5.4.2.2 | Bitácora de incidencias del proyecto |  | 2h | 2023-11-06 A | 2023-11-06 A | 185 | 100% |  | Alumno (jefe de proyecto); Alumno (arquitecto) | 2h | 2h | 55 | 55 |
| 187 | 1.2.5.4.2.3 | Riesgos |  | 2h | 2023-11-06 A | 2023-11-06 A | 186 | 100% |  | Alumno (jefe de proyecto); Alumno (arquitecto) | 4h | 4h | 110 | 110 |
| 188 | 1.2.5.4.3 | **Cierre del proyecto** |  | 1.5d | 2023-11-06 A | 2023-11-08 A |  | 100% |  |  | 10h | 10h | 290 | 290 |
| 189 | 1.2.5.4.3.1 | Planificación final |  | 2h | 2023-11-06 A | 2023-11-07 A | 187 | 100% |  | Alumno (jefe de proyecto); Alumno (arquitecto) | 2h | 2h | 55 | 55 |
| 190 | 1.2.5.4.3.2 | Informe final de riesgos |  | 2h | 2023-11-07 A | 2023-11-07 A | 189 | 100% |  | Alumno (arquitecto); Alumno (jefe de proyecto) | 2h | 2h | 55 | 55 |
| 191 | 1.2.5.4.3.3 | Presupuesto final de costes |  | 3h | 2023-11-07 A | 2023-11-08 A | 190 | 100% |  | Alumno (jefe de proyecto) | 3h | 3h | 90 | 90 |
| 192 | 1.2.5.4.3.4 | Informe de lecciones aprendidas |  | 3h | 2023-11-08 A | 2023-11-08 A | 191 | 100% |  | Alumno (arquitecto); Alumno (jefe de proyecto) | 3h | 3h | 90 | 90 |
| 193 | 1.2.5.5 | Estado del arte |  | 20h | 2023-09-20 A | 2023-09-29 A | 171 | 100% |  | Alumno (investigador) | 20h | 20h | 300 | 300 |

| ID | WBS | Task | Duration | Start | Finish | Predecessors | Complete | Resources | Work | Actual work | Cost | Actual cost |
| --- | --- | --- | --- | --- | --- | --- | --- | --- | --- | --- | --- | --- |
| 194 | 1.2.5.6 | **Descripción del sistema** | 10.25d | 2023-09-29 A | 2023-10-13 A |  | 100% |  | 32h | 32h | 480 | 480 |
| 195 | 1.2.5.6.1 | **Formulaciones** | 1d | 2023-09-29 A | 2023-10-02 A |  | 100% |  | 3h | 3h | 45 | 45 |
| 196 | 1.2.5.6.1.1 | Framework QUBO | 1h | 2023-09-29 A | 2023-09-29 A | 193 | 100% | Alumno (investigador) | 1h | 1h | 15 | 15 |
| 197 | 1.2.5.6.1.2 | Modelo de Ising | 2h | 2023-09-29 A | 2023-10-02 A | 196 | 100% | Alumno (investigador) | 2h | 2h | 30 | 30 |
| 198 | 1.2.5.6.2 | **Problemas** | 4.12d | 2023-10-02 A | 2023-10-06 A |  | 100% |  | 13h | 13h | 195 | 195 |
| 199 | 1.2.5.6.2.1 | Max-Cut | 2h | 2023-10-02 A | 2023-10-02 A | 197 | 100% | Alumno (investigador) | 2h | 2h | 30 | 30 |
| 200 | 1.2.5.6.2.2 | Programación lineal binaria | 3h | 2023-10-03 A | 2023-10-03 A | 199 | 100% | Alumno (investigador) | 3h | 3h | 45 | 45 |
| 201 | 1.2.5.6.2.3 | TSP | 3h | 2023-10-04 A | 2023-10-04 A | 200 | 100% | Alumno (investigador) | 3h | 3h | 45 | 45 |
| 202 | 1.2.5.6.2.4 | Problema de la mochila | 2h | 2023-10-05 A | 2023-10-05 A | 201 | 100% | Alumno (investigador) | 2h | 2h | 30 | 30 |
| 203 | 1.2.5.6.2.5 | Problema del coloreado de grafos | 3h | 2023-10-05 A | 2023-10-06 A | 202 | 100% | Alumno (investigador) | 3h | 3h | 45 | 45 |
| 204 | 1.2.5.6.3 | **Métodos** | 5.12d | 2023-10-06 A | 2023-10-13 A |  | 100% |  | 16h | 16h | 240 | 240 |
| 205 | 1.2.5.6.3.1 | **Annealing cuántico** | 1.88d | 2023-10-06 A | 2023-10-10 A |  | 100% |  | 5h | 5h | 75 | 75 |
| 206 | 1.2.5.6.3.1.1 | Computación adiabática cuántica | 3h | 2023-10-06 A | 2023-10-09 A | 203 | 100% | Alumno (investigador) | 3h | 3h | 45 | 45 |
| 207 | 1.2.5.6.3.1.2 | Annealing cuántico | 2h | 2023-10-09 A | 2023-10-10 A | 206 | 100% | Alumno (investigador) | 2h | 2h | 30 | 30 |
| 208 | 1.2.5.6.3.2 | **QAOA** | 3.25d | 2023-10-10 A | 2023-10-13 A |  | 100% |  | 11h | 11h | 165 | 165 |
| 209 | 1.2.5.6.3.2.1 | Definición | 2h | 2023-10-10 A | 2023-10-10 A | 207 | 100% | Alumno (investigador) | 2h | 2h | 30 | 30 |
| 210 | 1.2.5.6.3.2.2 | Algoritmo | 3h | 2023-10-11 A | 2023-10-11 A | 209 | 100% | Alumno (investigador) | 3h | 3h | 45 | 45 |
| 211 | 1.2.5.6.3.2.3 | Paso a circuitos | 6h | 2023-10-12 A | 2023-10-13 A | 210 | 100% | Alumno (investigador) | 6h | 6h | 90 | 90 |
| 212 | 1.2.5.7 | **Metodología de trabajo** | 5.67d | 2023-10-16 A | 2023-10-23 A |  | 100% |  | 10.08h | 10.08h | 151.25 | 151.25 |
| 213 | 1.2.5.7.1 | Explicación de métodos a utilizar | 2h | 2023-10-16 A | 2023-10-16 A | 211 | 100% | Alumno (investigador) | 2h | 2h | 30 | 30 |
| 214 | 1.2.5.7.2 | **Max-Cut** | 1.5d | 2023-10-16 A | 2023-10-17 A | 130 | 100% |  | 3.25h | 3.25h | 48.75 | 48.75 |
| 215 | 1.2.5.7.2.1 | Datos utilizados | 15min | 2023-10-16 A | 2023-10-16 A | 213 | 100% | Alumno (investigador) | 0.25h | 0.25h | 3.75 | 3.75 |
| 216 | 1.2.5.7.2.2 | Formulación del problema | 1h | 2023-10-16 A | 2023-10-16 A | 215 | 100% | Alumno (ingeniero) | 1h | 1h | 15 | 15 |
| 217 | 1.2.5.7.2.3 | Ejecución del problema | 2h | 2023-10-16 A | 2023-10-17 A | 216 | 100% | Alumno (ingeniero) | 2h | 2h | 30 | 30 |

| ID | WBS | Task | Duration | Start | Finish | Predecessors | Complete | Resources | Work | Actual work | Cost | Actual cost |
| --- | --- | --- | --- | --- | --- | --- | --- | --- | --- | --- | --- | --- |
| 218 | 1.2.5.7.3 | **TSP** | 1.75d | 2023-10-18 A | 2023-10-19 A | 134 | 100% |  | 3.25h | 3.25h | 48.75 | 48.75 |
| 219 | 1.2.5.7.3.1 | Datos utilizados | 15min | 2023-10-18 A | 2023-10-18 A | 217 | 100% | Alumno (investigador) | 0.25h | 0.25h | 3.75 | 3.75 |
| 220 | 1.2.5.7.3.2 | Formulación del problema | 2h | 2023-10-18 A | 2023-10-18 A | 219 | 100% | Alumno (ingeniero) | 2h | 2h | 30 | 30 |
| 221 | 1.2.5.7.3.3 | Ejecución del problema | 1h | 2023-10-19 A | 2023-10-19 A | 220 | 100% | Alumno (ingeniero) | 1h | 1h | 15 | 15 |
| 222 | 1.2.5.7.4 | **Problema de la mochila** | 0.72d | 2023-10-20 A | 2023-10-20 A | 138 | 100% |  | 1h | 1h | 15 | 15 |
| 223 | 1.2.5.7.4.1 | Datos utilizados | 15min | 2023-10-20 A | 2023-10-20 A | 221 | 100% | Alumno (investigador) | 0.25h | 0.25h | 3.75 | 3.75 |
| 224 | 1.2.5.7.4.2 | Formulación del problema | 30min | 2023-10-20 A | 2023-10-20 A | 223 | 100% | Alumno (ingeniero) | 0.5h | 0.5h | 7.5 | 7.5 |
| 225 | 1.2.5.7.4.3 | Ejecución del problema | 15min | 2023-10-20 A | 2023-10-20 A | 224 | 100% | Alumno (ingeniero) | 0.25h | 0.25h | 3.75 | 3.75 |
| 226 | 1.2.5.7.5 | **Problema del coloreado de grafos** | 0.67d | 2023-10-23 A | 2023-10-23 A | 142 | 100% |  | 0.58h | 0.58h | 8.75 | 8.75 |
| 227 | 1.2.5.7.5.1 | Datos utilizados | 15min | 2023-10-23 A | 2023-10-23 A | 225 | 100% | Alumno (investigador) | 0.25h | 0.25h | 3.75 | 3.75 |
| 228 | 1.2.5.7.5.2 | Formulación del problema | 10min | 2023-10-23 A | 2023-10-23 A | 227 | 100% | Alumno (ingeniero) | 0.17h | 0.17h | 2.5 | 2.5 |
| 229 | 1.2.5.7.5.3 | Ejecución del problema | 10min | 2023-10-23 A | 2023-10-23 A | 228 | 100% | Alumno (ingeniero) | 0.17h | 0.17h | 2.5 | 2.5 |
| 230 | 1.2.5.8 | **Resultados obtenidos** | 2.12d | 2023-10-24 A | 2023-10-26 A |  | 100% |  | 7h | 7h | 105 | 105 |
| 231 | 1.2.5.8.1 | **Presentación de los resultados** | 1.12d | 2023-10-24 A | 2023-10-25 A |  | 100% |  | 4h | 4h | 60 | 60 |
| 232 | 1.2.5.8.1.1 | Max-Cut | 1h | 2023-10-24 A | 2023-10-24 A | 229 | 100% | Alumno (investigador) | 1h | 1h | 15 | 15 |
| 233 | 1.2.5.8.1.2 | TSP | 1h | 2023-10-24 A | 2023-10-24 A | 232 | 100% | Alumno (investigador) | 1h | 1h | 15 | 15 |
| 234 | 1.2.5.8.1.3 | Problema de la mochila | 1h | 2023-10-24 A | 2023-10-24 A | 233 | 100% | Alumno (investigador) | 1h | 1h | 15 | 15 |
| 235 | 1.2.5.8.1.4 | Problema del coloreado de grafos | 1h | 2023-10-25 A | 2023-10-25 A | 234 | 100% | Alumno (investigador) | 1h | 1h | 15 | 15 |
| 236 | 1.2.5.8.2 | Discusión de los resultados | 3h | 2023-10-25 A | 2023-10-26 A | 235 | 100% | Alumno (investigador) | 3h | 3h | 45 | 45 |
| 237 | 1.2.5.9 | **Conclusiones y trabajo futuro** | 0.91d | 2023-10-26 A | 2023-10-27 A |  | 100% |  | 2.25h | 2.25h | 33.75 | 33.75 |
| 238 | 1.2.5.9.1 | Trabajo futuro | 2h | 2023-10-26 A | 2023-10-26 A | 236 | 100% | Alumno (investigador) | 2h | 2h | 30 | 30 |
| 239 | 1.2.5.9.2 | Difusión de resultados | 15min | 2023-10-27 A | 2023-10-27 A | 238 | 100% | Alumno (investigador) | 0.25h | 0.25h | 3.75 | 3.75 |
| 240 | 1.2.5.10 | Bibliografía | 15min | 2023-10-27 A | 2023-10-27 A | 239 | 100% | Alumno (investigador) | 0.25h | 0.25h | 3.75 | 3.75 |
| 241 | 1.2.5.11 | **Anexos** | 5.81d | 2023-10-27 A | 2023-11-03 A |  | 100% |  | 17h | 17h | 330 | 330 |
| 242 | 1.2.5.11.1 | Plan de gestión de riesgos | 2h | 2023-10-27 A | 2023-10-27 A | 240 | 100% | Alumno (investigador) | 2h | 2h | 30 | 30 |
| 243 | 1.2.5.11.2 | Presupuesto | 5h | 2023-10-27 A | 2023-10-27 A | 242 | 100% | Alumno (jefe de proyecto) | 5h | 5h | 150 | 150 |
| 244 | 1.2.5.11.3 | Aplicación web | 10h | 2023-10-30 A | 2023-11-03 A | 243, 146 | 100% | Alumno (ingeniero) | 10h | 10h | 150 | 150 |
| 245 | 1.2.6 | Reunión de cierre | 1h | 2023-11-08 A | 2023-11-08 A | 165 | 100% | Alumno (jefe de proyecto) | 1h | 1h | 30 | 30 |
